| id | name | startDate | endDate | priority | barScale | progress | type | parentId | dependencies |
| --- | --- | --- | --- | --- | --- | --- | --- | --- | --- |
| 1 | Kitchen Remodel | 2026-06-01T00:00:00.000Z | 2026-08-10T00:00:00.000Z | medium | 1 | 0 | group |  |  |
| 2 | Lock design | 2026-06-01T00:00:00.000Z | 2026-06-08T00:00:00.000Z | high | 1 | 0 | task | 1 |  |
| 3 | Order cabinets | 2026-06-08T00:00:00.000Z | 2026-06-09T00:00:00.000Z | medium | 1 | 0 | milestone | 1 | 2 FS |
| 4 | Order appliances | 2026-06-08T00:00:00.000Z | 2026-06-11T00:00:00.000Z | medium | 1 | 0 | task | 1 |  |
| 5 | Order tile and flooring | 2026-06-09T00:00:00.000Z | 2026-06-12T00:00:00.000Z | medium | 1 | 0 | task | 1 |  |
| 6 | Demolition | 2026-06-15T00:00:00.000Z | 2026-06-18T00:00:00.000Z | medium | 1 | 0 | task | 1 |  |
| 7 | Framing changes | 2026-06-18T00:00:00.000Z | 2026-06-21T00:00:00.000Z | medium | 1 | 0 | task | 1 | 6 FS |
| 8 | Plumbing rough-in | 2026-06-21T00:00:00.000Z | 2026-06-24T00:00:00.000Z | medium | 1 | 0 | task | 1 | 7 FS |
| 9 | Electrical rough-in | 2026-06-22T00:00:00.000Z | 2026-06-25T00:00:00.000Z | medium | 1 | 0 | task | 1 | 7 FS |
| 10 | Rough inspection | 2026-06-26T00:00:00.000Z | 2026-06-27T00:00:00.000Z | medium | 1 | 0 | milestone | 1 |  |
| 11 | Drywall | 2026-06-27T00:00:00.000Z | 2026-07-03T00:00:00.000Z | medium | 1 | 0 | task | 1 | 10 FS |
| 12 | Paint | 2026-07-03T00:00:00.000Z | 2026-07-07T00:00:00.000Z | medium | 1 | 0 | task | 1 | 11 FS |
| 13 | Flooring install | 2026-07-07T00:00:00.000Z | 2026-07-11T00:00:00.000Z | medium | 1 | 0 | task | 1 | 12 FS |
| 14 | Cabinet install | 2026-07-20T00:00:00.000Z | 2026-07-23T00:00:00.000Z | medium | 1 | 0 | task | 1 | 13 FS |
| 15 | Countertop template | 2026-07-23T00:00:00.000Z | 2026-07-24T00:00:00.000Z | medium | 1 | 0 | milestone | 1 | 14 FS |
| 16 | Backsplash tile | 2026-07-24T00:00:00.000Z | 2026-07-28T00:00:00.000Z | medium | 1 | 0 | task | 1 |  |
| 17 | Countertop install | 2026-07-31T00:00:00.000Z | 2026-08-01T00:00:00.000Z | medium | 1 | 0 | milestone | 1 |  |
| 18 | Appliance install | 2026-08-01T00:00:00.000Z | 2026-08-03T00:00:00.000Z | medium | 1 | 0 | task | 1 |  |
| 19 | Plumbing fixtures | 2026-08-03T00:00:00.000Z | 2026-08-05T00:00:00.000Z | medium | 1 | 0 | task | 1 |  |
| 20 | Final inspection | 2026-08-07T00:00:00.000Z | 2026-08-08T00:00:00.000Z | medium | 1 | 0 | milestone | 1 |  |
| 21 | Punch list | 2026-08-07T00:00:00.000Z | 2026-08-10T00:00:00.000Z | medium | 1 | 0 | task | 1 |  |
